# Example Project Plan for RMP01

Schedule from MS Project, 2009-01-05 to 2013-06-27.
BC Consultants, Inc.

## Calendars

- Standard: Mon-Fri 08:00-12:00, 13:00-17:00; Sat-Sun off. Exceptions (off unless hours are given): 2009-01-19, 2009-05-25, 2009-07-03, 2009-09-07, 2009-11-26 to 2009-11-27, 2009-12-24 to 2009-12-25, 2010-01-01, 2010-01-18, 2010-05-31, 2010-07-05, 2010-09-06, 2010-11-25 to 2010-11-26, 2010-12-24, 2010-12-27, 2011-01-03, 2011-01-24, 2011-05-30, 2011-07-04, 2011-09-05, 2011-11-24 to 2011-11-25, 2011-12-26, 2012-01-02, 2012-01-23, 2012-05-28, 2012-07-04, 2012-09-03, 2012-11-22 to 2012-11-23, 2012-12-24 to 2012-12-25, 2013-01-01, 2013-01-21, 2013-05-27.

## Resources

| Resource |
| --- |
| Calendar Days |

## Schedule

| ID | WBS | Task | Type | Duration | Start | Finish | Predecessors | Total slack | Work |
| --- | --- | --- | --- | --- | --- | --- | --- | --- | --- |
| 1 | 1 | **Example Resource Management Plan (RMP)** |  | 1132d | 2009-01-05 | 2013-06-27 |  | 0d | 2640h |
| 2 | 1.1 | **Project Management** |  | 955d | 2009-04-06 | 2013-01-17 |  | 10d |  |
| 3 | 1.1.1 | **Develop Project Management Plan** |  | 20d | 2009-04-06 | 2009-05-01 |  | 10d |  |
| 4 | 1.1.1.1 | Develop WBS, Risk Plans, Estimates & CPM Schedule |  | 20d | 2009-04-06 | 2009-05-01 | 29 | 10d |  |
| 5 | 1.1.2 | **Internal Status Review Meetings** |  | 950d | 2009-04-06 | 2013-01-10 |  | 103d |  |
| 6 | 1.1.2.1 | Weekly Status Meetings |  | 950d | 2009-04-06 | 2013-01-10 | 29 | 103d |  |
| 7 | 1.1.3 | **BLM/Contractor Status Review Meetings** |  | 800d | 2009-11-12 | 2013-01-17 |  | 98d |  |
| 8 | 1.1.3.1 | Monthly Status Meetings with Contractor |  | 800d | 2009-11-12 | 2013-01-17 | 62 | 98d |  |
| 9 | 1.1.4 | **Change Management** |  | 950d | 2009-04-06 | 2013-01-10 |  | 103d |  |
| 10 | 1.1.4.1 | Process Proposed Changes |  | 950d | 2009-04-06 | 2013-01-10 | 29 | 103d |  |
| 11 | 1.2 | **Plan Groundwork** |  | 234d | 2009-01-05 | 2009-12-04 |  | 0d |  |
| 12 | 1.2.1 | **Existing Plan Evaluation** |  | 63d | 2009-01-05 | 2009-04-02 |  | 0d |  |
| 13 | 1.2.1.1 | Start RMP/EIS Groundwork | milestone | 0d | 2009-01-05 | 2009-01-05 |  | 0d |  |
| 14 | 1.2.1.2 | **Conduct & Summarize Interviews** |  | 28d | 2009-01-05 | 2009-02-12 |  | 0d |  |
| 15 | 1.2.1.2.1 | Assign Plan Leader |  | 1d | 2009-01-05 | 2009-01-05 | 13 | 0d |  |
| 16 | 1.2.1.2.2 | Assemble Interdisciplinary Team (IDT) |  | 1d | 2009-01-06 | 2009-01-06 | 15 | 0d |  |
| 17 | 1.2.1.2.3 | Review Existing Plan and All Updates |  | 9d | 2009-01-07 | 2009-01-20 | 16 | 0d |  |
| 18 | 1.2.1.2.4 | Develop Questionairre |  | 2d | 2009-01-21 | 2009-01-22 | 17 | 0d |  |
| 19 | 1.2.1.2.5 | Conduct Interviews with All Resource Specialists |  | 10d | 2009-01-23 | 2009-02-05 | 18 | 0d |  |
| 20 | 1.2.1.2.6 | Summarize Interviews |  | 5d | 2009-02-06 | 2009-02-12 | 19 | 0d |  |
| 21 | 1.2.1.3 | **Write Draft Plan Evaluation Report & Approve** |  | 35d | 2009-02-13 | 2009-04-02 |  | 0d |  |
| 22 | 1.2.1.3.1 | Decisions to Carry Forward, Revise, Drop |  | 5d | 2009-02-13 | 2009-02-19 | 20 | 0d |  |
| 23 | 1.2.1.3.2 | Field Office (FO) Review |  | 20d | 2009-02-20 | 2009-03-19 | 22 | 0d |  |
| 24 | 1.2.1.3.3 | State Director (SD) Concurrance |  | 10d | 2009-03-20 | 2009-04-02 | 23 | 0d |  |
| 25 | 1.2.1.3.4 | Plan Groundwork Complete | milestone | 0d | 2009-04-02 | 2009-04-02 | 24 | 0d |  |

Notes:
- 4: Develop Project Management Plan (PMP) including: Work Breakdown Structure, Risk Management Plan, Detailed Estimate, Critical Path Schedule, Staffing Plan, etc. Review with all team members and approve.
- 6: Prior to the status meeting: (1) input status for all activities in the CMP schedule; and (2) identify any significant problems. During the status meeting: (1) discuss significant problems to determine corrective actions; or (2) assign problems to team members as action items to resolve.
- 8: Prior to the status meeting, the contractor should identify significant problems with proposed solutions. During the status meeting: (1) BLM and the contractor will discuss monthly status and potential solutions to significant problems. BLM will have final approval authority for all contractor proposed solutions.
- 10: PL initiates Change Request Form for all internal and external changes. All changes are formally reviewed and analyzed for impacts to cost and schedule. Decision is made to either approve or reject each proposed change.
- 15: Establish project management by appointing the PL.
- 16: Determine the names of the resource specialts that will be assigned to review the existing plan. Decide the percentage of time each person will be expected to devote to the existing plan review.
- 17: Locate the existing plan and all updates. Distribute copies to appropriate team members for review. Document what is expected as the end result of the reviews. Complete reviews.
- 18: Review existing questionairres and develop questionairre to interview resource specialts.
- 19: Expect interviews to take 2-4 hours for each resource specialist. Document results of each interview.
- 20: Consolidate results of all interviews and summarize.
- 22: Draft Existing Plan Evaluation Report.

| ID | WBS | Task | Type | Duration | Start | Finish | Predecessors | Total slack | Free slack |
| --- | --- | --- | --- | --- | --- | --- | --- | --- | --- |
| 26 | 1.2.2 | **Pre-Plan** |  | 68d | 2009-04-02 | 2009-07-09 |  | 0d |  |
| 27 | 1.2.2.1 | Start Preplan | milestone | 0d | 2009-04-02 | 2009-04-02 | 25 | 0d |  |
| 28 | 1.2.2.2 | **Draft Preplan Analysis Report** |  | 38d | 2009-04-03 | 2009-05-27 |  | 0d |  |
| 29 | 1.2.2.2.1 | Assemble ID Team |  | 1d | 2009-04-03 | 2009-04-03 | 27 | 0d |  |
| 30 | 1.2.2.2.2 | Document Preliminary Issues & Management Concerns |  | 20d | 2009-04-06 | 2009-05-01 | 29 | 0d |  |
| 31 | 1.2.2.2.3 | Document Planning Criteria |  | 5d | 2009-05-04 | 2009-05-08 | 30 | 0d |  |
| 32 | 1.2.2.2.4 | Identify Data Gaps |  | 5d | 2009-05-11 | 2009-05-15 | 31 | 0d |  |
| 33 | 1.2.2.2.5 | Summarize Schedule & Budget |  | 2d | 2009-05-18 | 2009-05-19 | 4, 32 | 0d |  |
| 34 | 1.2.2.2.6 | Complete Draft Preplan Analysis Report |  | 5d | 2009-05-20 | 2009-05-27 | 33 | 0d |  |
| 35 | 1.2.2.3 | **Initiate Administrative Record** |  | 5d | 2009-05-28 | 2009-06-03 |  | 25d |  |
| 36 | 1.2.2.3.1 | Develop Administrative Record Process |  | 5d | 2009-05-28 | 2009-06-03 | 34 | 25d |  |
| 37 | 1.2.2.4 | **Review & Approve Preplan** |  | 30d | 2009-05-28 | 2009-07-09 |  | 0d |  |
| 38 | 1.2.2.4.1 | FO/SO/WO/DOI Review, Revise, Approve |  | 30d | 2009-05-28 | 2009-07-09 | 34 | 0d |  |
| 39 | 1.2.2.4.2 | Preplan Complete | milestone | 0d | 2009-07-09 | 2009-07-09 | 38, 36 | 0d |  |
| 40 | 1.2.3 | **Start Collecting Baseline Data Identified in Data Gaps** |  | 140d | 2009-05-18 | 2009-12-04 |  | 75d |  |
| 41 | 1.2.3.1 | **Collect Inventory Data** |  | 140d | 2009-05-18 | 2009-12-04 |  | 75d |  |
| 42 | 1.2.3.1.1 | Data Collection |  | 140d | 2009-05-18 | 2009-12-04 | 32 | 75d | 55d |
| 43 | 1.2.4 | **Develop On-Going Communication Strategy** |  | 50d | 2009-07-10 | 2009-09-18 |  | 951d |  |
| 44 | 1.2.4.1 | **Internal Communications** |  | 5d | 2009-07-10 | 2009-07-16 |  | 951d |  |
| 45 | 1.2.4.1.1 | Develop PL, CT, IDT Communication Plan |  | 5d | 2009-07-10 | 2009-07-16 | 38 | 951d | 0d |
| 46 | 1.2.4.2 | **External Communications** |  | 45d | 2009-07-17 | 2009-09-18 |  | 951d |  |
| 47 | 1.2.4.2.1 | Develop External Communication Plan |  | 10d | 2009-07-17 | 2009-07-30 | 45 | 951d | 0d |
| 48 | 1.2.4.2.2 | Develop or Revise Mailing List |  | 15d | 2009-07-31 | 2009-08-20 | 47 | 951d | 0d |
| 49 | 1.2.4.2.3 | Design Website |  | 10d | 2009-08-21 | 2009-09-03 | 48 | 951d | 0d |
| 50 | 1.2.4.2.4 | Determine & Input Initial Website Content |  | 10d | 2009-09-04 | 2009-09-18 | 49 | 951d |  |

Notes:
- 27: Milestone representing the beginning of work on the preplan.
- 29: Determine the names of the resource specialts that will be assigned to work on the preplan. Decide the percentage of time each person will be expected to devote to the preplan.
- 30: Review existing information and identify the preliminary issues or land use problems. Document the preliminary issues and management concerns. Conduct reviews, respond to comments, and coordinate with collaborators.
- 31: Review existing information and identify the preliminary planning criteria. Document the preliminary planning criteria including factors for analysis. Conduct reviews, respond to comments, and coordinate with collaborators.
- 32: Review existing inventory data and GIS. Determine: What data do we have, What data do we need, and What data do we want? Summarize data that needs to be collected, updated, compiled, and/or put into digital format for use in the planning process and for development of the Plan maps. Provide rationale for why additional resource data must be gathered.
- 33: Review the estimate and critical path schedule in the PMP. Summarize the key milestones and milestone dates. Summarize the estimates for the budget.
- 34: Develop team lists and document roles, responsibilities, and authority for: 1) Management Team, 2) Core Team, 3) Interdisciplinary Team, 4) BLM State Office, and 5) BLM Washington Office. Document cooperation, consultation, and coordination with local and national entities: 1) Public, 2) Advisory Committees, 3) Advisory Councils, 4) Partnerships, 5) Experts, and 6) Others. / Prepare a draft of the Preplan Analysis Report containing the following: 1) Introduction and Background, 2) Purpose and Need for RMP/EIS, 3) Planning Area Description, 4) Goals and Objectives for the Planning Area, 5) Anticipated Issues, Management Concerns, and Preliminary Planning Criteria, 6) Data and Geographical Information System Needs, 7) Participants in the Process, 8) Format and Process for the RMP, 9) Public Notification Process and Stakeholders List, 10) Field Office Staffing, Office Space, and Equipment Needs, 11) Appendix A Maps, 12) Appendix B RMP Preparation Schedule, 13) Appendix C Public Participation Schedule, 14) Appendix D Contact/Comment Documentation, and 15) Appendix E Land Exchanges.
- 38: Conduct necessary reviews of draft, respond to comments, finalize, print, distribute, and publish on the BLM website the Preplan Analysis Report.
- 39: Milestone representing the final approved Preplan Analysis Report is printed and distributed.
- 42: Develop inventory data and GIS revision strategy and initiate revision of GIS themes. Existing GIS themes will be updated, reviewed, edited, and finalized. / The following guidelines will be adhered to as data is developed for this planning effort: / 1. Existing data will be used whenever possible and new data will be collected only when absolutely necessary. Collection of new data will require approval. All new data will be collected to established data standards. Existing data will be converted to accepted and established data standards, if feasible. If conversion is determined to be unfeasible, a determination will be made if conversion to established standards is required. / 2. The development of redundant data will be avoided by extensive coordination with our data partners. Data from existing sources will be used when possible. / 3. Data for this planning effort will be integrated into seamless corporate data sets. / 4. Data standards from other agencies will be adopted when appropriate. Data standards will be developed and documented by BLM with our statewide data partners as appropriate. Data category standards teams, which include State data stewards, resource specialists, and GIS specialists from BLM and other agencies, will be used as necessary. The national BLM data stewards will be included in the review process as appropriate. / 5. All geospatial data used in this planning effort will be documented with Federal Geographic Data Committee (FGDC) compliant meta data. / 6. Data sharing with the public will be accomplished through the use of BLM GIS data servers and interactive GIS Map Servers connected through the Internet, if available. The national BLM website design guidelines and deployment strategy will be followed. / 7. Data will also be available to the public through links to the State Geographic Information Database (SGID) as appropriate, and as existing laws and regulations allow. / 8. Existing GIS-related agreements/partnerships will be used to supplement BLM resources for the data development and data integration efforts. Partners that are familiar with these data sets and that have a proven record of accomplishment will be used. / 9. Data developed to support this planning effort will be consistent with existing State BLM GIS Implementation Plan process/procedures to achieve a consistent corporate geospatial database in State BLM.
- 48: Develop mailing list of interested parties for public involvement.

| ID | WBS | Task | Type | Duration | Start | Finish | Predecessors | Total slack | Free slack | Resources | Work |
| --- | --- | --- | --- | --- | --- | --- | --- | --- | --- | --- | --- |
| 51 | 1.2.5 | **Initiate On-Going Collaboration** |  | 23d | 2009-07-10 | 2009-08-11 |  | 978d |  |  |  |
| 52 | 1.2.5.1 | Interagency, Intergovernment, Native Americans |  | 20d | 2009-07-10 | 2009-08-06 | 38 | 978d | 0d |  |  |
| 53 | 1.2.5.2 | Develop Public Collaboration Plan |  | 2d | 2009-08-07 | 2009-08-10 | 52 | 978d | 0d |  |  |
| 54 | 1.2.5.3 | Advisory Committees |  | 1d | 2009-08-11 | 2009-08-11 | 53 | 978d |  |  |  |
| 55 | 1.2.6 | **Contracting** |  | 93d | 2009-07-10 | 2009-11-18 |  | 0d |  |  |  |
| 56 | 1.2.6.1 | Determine Contracting Strategy |  | 3d | 2009-07-10 | 2009-07-14 | 39 | 0d |  |  |  |
| 57 | 1.2.6.2 | Develop SOW |  | 20d | 2009-07-15 | 2009-08-11 | 56 | 0d |  |  |  |
| 58 | 1.2.6.3 | Develop Request for Proposal (RFP) |  | 20d | 2009-08-12 | 2009-09-09 | 57 | 0d |  |  |  |
| 59 | 1.2.6.4 | Contractors Submit Bid |  | 30d | 2009-09-10 | 2009-10-21 | 58 | 0d |  |  |  |
| 60 | 1.2.6.5 | Evaluate & Recommend |  | 5d | 2009-10-22 | 2009-10-28 | 59 | 0d |  |  |  |
| 61 | 1.2.6.6 | Issue Contract |  | 10d | 2009-10-29 | 2009-11-11 | 60 | 0d |  |  |  |
| 62 | 1.2.6.7 | Contract Awarded | milestone | 0d | 2009-11-11 | 2009-11-11 | 61 | 0d |  |  |  |
| 63 | 1.2.6.8 | Brief Unsuccessful Bidders |  | 5d | 2009-11-12 | 2009-11-18 | 62 | 15d |  |  |  |
| 64 | 1.2.7 | **Notice of Intent (NOI)** |  | 32d | 2009-07-10 | 2009-08-24 |  | 26d |  |  |  |
| 65 | 1.2.7.1 | Write, Revise & Finalize NOI |  | 1d | 2009-07-10 | 2009-07-10 | 39 | 26d | 0d |  |  |
| 66 | 1.2.7.2 | Write, Revise, & Finalize Briefing Paper |  | 1d | 2009-07-13 | 2009-07-13 | 65 | 26d | 0d |  |  |
| 67 | 1.2.7.3 | FO/SO Review, Respond to Comments, Revise, Finalize |  | 20d | 2009-07-14 | 2009-08-10 | 66 | 26d | 0d |  |  |
| 68 | 1.2.7.4 | Publish NOI in Federal Register, Local Media, Website |  | 10d | 2009-08-11 | 2009-08-24 | 67 | 26d | 0d |  |  |
| 69 | 1.2.7.5 | NOI Complete | milestone | 0d | 2009-08-24 | 2009-08-24 | 68 | 26d | 0d |  |  |
| 70 | 1.3 | **Scoping** |  | 126d | 2009-08-24 | 2010-02-25 |  | 26d |  |  | 240h |
| 71 | 1.3.1 | **Public Review & Comment Period (Calendar Days)** |  | 21d | 2009-08-24 | 2009-09-23 |  | 26d |  |  | 240h |
| 72 | 1.3.1.1 | Start Scoping | milestone | 0d | 2009-08-24 | 2009-08-24 | 69 | 26d | 0d |  |  |
| 73 | 1.3.1.2 | Public Review & Comment Period |  | 30d | 2009-08-25 | 2009-09-23 | 72 | 55d |  | Calendar Days | 240h |
| 74 | 1.3.2 | **Analysis of the Management Situation (AMS)** |  | 60d | 2009-08-25 | 2009-11-17 |  | 26d |  |  |  |
| 75 | 1.3.2.1 | IDT Draft AMS |  | 30d | 2009-08-25 | 2009-10-06 | 72 | 26d | 0d |  |  |
| 76 | 1.3.2.2 | FO Review Draft AMS |  | 20d | 2009-10-07 | 2009-11-03 | 75 | 26d | 0d |  |  |
| 77 | 1.3.2.3 | IDT Incorporate Comments |  | 5d | 2009-11-04 | 2009-11-10 | 76 | 26d | 0d |  |  |
| 78 | 1.3.2.4 | FO Approve AMS |  | 5d | 2009-11-11 | 2009-11-17 | 77 | 26d | 0d |  |  |
| 79 | 1.3.2.5 | AMS Complete | milestone | 0d | 2009-11-17 | 2009-11-17 | 78 | 909d |  |  |  |

Notes:
- 52: Initiate collaboration with Cooperating Agencies, (up to ten cooperating agencies may be involved with this planning effort). Determine and accomplish logistics for all meetings (specific meeting location, time, audio/visual equipment, seating, etc.). Facilitate a minimum of eight meetings within 6 months. Agencies include, but are not limited to, the following: 1) State Department of Natural Resources represented by Division of Wildlife Resources and the Division of Oil, Gas, and Mining, 2) State Department of Environmental Quality represented by the State Division of Air Quality, 3) County Governments: W County, X County, and Y County, 4) Tribe, and 5) Federal Agencies represented by the Bureau of Indian Affairs
- 65: Write, review, and finalize NOI. Publish NOI in the Federal Register, local media, mailings, etc.

| ID | WBS | Task | Type | Duration | Start | Finish | Predecessors | Total slack |
| --- | --- | --- | --- | --- | --- | --- | --- | --- |
| 80 | 1.3.3 | **Scoping Meetings** |  | 20d | 2009-11-12 | 2009-12-11 |  | 0d |
| 81 | 1.3.3.1 | Draft, Review, Approve, Produce, Publish Media Notification of Scoping Meetings |  | 5d | 2009-11-12 | 2009-11-18 | 62, 72 | 0d |
| 82 | 1.3.3.2 | Develop Materials for Scoping Meetings |  | 5d | 2009-11-19 | 2009-11-25 | 81 | 0d |
| 83 | 1.3.3.3 | Conduct Scoping Meetings |  | 10d | 2009-11-30 | 2009-12-11 | 82 | 0d |
| 84 | 1.3.4 | **Consultation/Coordination/Collaboration** |  | 20d | 2009-08-25 | 2009-09-22 |  | 56d |
| 85 | 1.3.4.1 | Native American |  | 15d | 2009-08-25 | 2009-09-15 | 72 | 61d |
| 86 | 1.3.4.2 | USFWS (Section 7) |  | 5d | 2009-08-25 | 2009-08-31 | 72 | 71d |
| 87 | 1.3.4.3 | Cultural (Section 106) |  | 5d | 2009-08-25 | 2009-08-31 | 72 | 71d |
| 88 | 1.3.4.4 | Other Local, State, Federal, Interagency |  | 20d | 2009-08-25 | 2009-09-22 | 72 | 56d |
| 89 | 1.3.5 | **Scoping Report** |  | 50d | 2009-12-14 | 2010-02-25 |  | 0d |
| 90 | 1.3.5.1 | Document Information from Public Comment |  | 10d | 2009-12-14 | 2009-12-29 | 88, 87, 85, 86, 62, 83, 63, 73 | 0d |
| 91 | 1.3.5.2 | Write Scoping Report |  | 10d | 2009-12-30 | 2010-01-13 | 90, 78 | 0d |
| 92 | 1.3.5.3 | Review Scoping Report |  | 20d | 2010-01-14 | 2010-02-11 | 91 | 0d |
| 93 | 1.3.5.4 | Incorporate Comments |  | 5d | 2010-02-12 | 2010-02-18 | 92 | 0d |
| 94 | 1.3.5.5 | Develop, Review, Approve, Produce, Publish Media Notification (Scoping Comments) |  | 5d | 2010-02-19 | 2010-02-25 | 93 | 0d |
| 95 | 1.3.5.6 | Scoping Report Complete | milestone | 0d | 2010-02-25 | 2010-02-25 | 94 | 0d |
| 96 | 1.4 | **Draft RMP/EIS** |  | 434d | 2010-02-25 | 2011-11-11 |  | 0d |
| 97 | 1.4.1 | **Analysis of the Affected Environment** |  | 55d | 2010-02-25 | 2010-05-13 |  | 0d |
| 98 | 1.4.1.1 | Start Draft RMP/EIS | milestone | 0d | 2010-02-25 | 2010-02-25 | 95 | 0d |
| 99 | 1.4.1.2 | **Collect Remaining Issue Based Data** |  | 10d | 2010-02-26 | 2010-03-11 |  | 20d |
| 100 | 1.4.1.2.1 | Collect Data (Minimal Remaining Data Required) |  | 10d | 2010-02-26 | 2010-03-11 | 42, 98 | 20d |
| 101 | 1.4.1.3 | **Mineral Potential Reports** |  | 30d | 2010-02-26 | 2010-04-08 |  | 0d |
| 102 | 1.4.1.3.1 | Draft Mineral Potential Assessment Report |  | 20d | 2010-02-26 | 2010-03-25 | 98 | 0d |
| 103 | 1.4.1.3.2 | Review & Finalize |  | 10d | 2010-03-26 | 2010-04-08 | 102 | 0d |

Notes:
- 83: Design collaborative community based public involvement strategies including appropriate reviews, comments, and responses. Determine and accomplish logistics for all meetings (specific meeting locations, time, audio/visual equipment, seating, etc.). Facilitate a minimum of six open house meetings. / Initiate preliminary scoping through development of a preliminary planning bulletin on Opportunities for Collaborative Planning. Bulletin is developed, reviewed, and mailed to interested parties as identified on BLMs mailing list (estimated to be 1,000 contacts). / Encourage public participation beyond the initial open house meetings. Efforts are expected to include some of the following: conducting public information meetings, workshops, small group presentations, field trips, issuing news releases, mailings, newsletters, paid newspaper advertisements, radio/TV announcements, Federal Register Notices, brochures/booklets/pamphlets, and informal contacts. BLM will ensure complete public involvement and dissemination of information pertaining to this project. As scoping progresses, using the scoping record, BLM will identify and document informal networks (publics interested in specific types of issues, i.e., wildlife, oil and gas, etc.). BLM will initiate collaboration with these informal (public-at-large) networks. / Periodic progress reports to interested parties will be prepared to provide up-to-date information on the RMP/EIS process.
- 86: Collect available data on those species identified by the U.S. Fish and Wildlife Service.
- 90: All documentation will be BLM website compatible. Prepare a system to document and track all public comments. Prepare copies of notes. Gather, screen, and evaluate ideas from public, private, tribal, and internal sources. Categorize scoping comments and draft responses to scoping comments. Conduct internal reviews of draft responses and finalize. Compile issues. Write scoping report.
- 100: Attend a minimum of three meetings with BLM Cooperative Ecosystem Study Unit partners to keep apprized of the following five ongoing regional assessments (for the base line resource assessment for this RMP): 1) Big game crucial habitat study, 2) Greater sage grouse habitat study, 3) Feriginous hawk habitat study, 4) Nesting inventories, 5) Impact of sediment loading on threatened and endangered (T&E) species in Boyne and Jordan Rivers. / Work with selected partners in collecting relevant baseline data on various social and economic parameters useful to the RMP process. At a minimum, it is expected that the following data will be needed for the process: / ·Basic county profiles on demographics, including population, age, size, ethnicity, in and out migration, etc. / ·Basic economic information, including income and employment data. / ·Basic social profiling including human and social resource units, which may include information on community capacity to absorb change and social attitudes. / ·Census data for determining extent of economic justice areas. / ·Data necessary to determine values of certain commodities or uses that result from public lands, such as the values of oil and gas leasing and production, or recreational use of the public lands. / All data will be used to support a defendable socio-economic input analysis of the various planning alternatives. Collect relevant socio-economic baseline data and provide a draft report. Review, comment, and coordinate report findings with collaborators. Finalize report.
- 102: Initiate development of Mineral Potential Report in cooperation with BLM and cooperating agencies (CA). The Bureau of Land Management requires a Mineral Potential Assessment Report be prepared to help evaluate the occurrence of mineral resources within the Planning Area boundaries. This provides the decision maker a better understanding of mineral resources in the area and the importance of those mineral resources in the context of future land use allocations. Occurrence potential, which is defined in BLM Manual 3031 (Illustration 3), refers to the potential for the presence (occurrence) of a concentration of one or more energy and/or mineral resources. Draft and Final Mineral Potential Assessment Report will be prepared and coordinated with cooperators. Comments will be responded to and report finalized.

| ID | WBS | Task | Type | Duration | Start | Finish | Predecessors | Total slack | Free slack |
| --- | --- | --- | --- | --- | --- | --- | --- | --- | --- |
| 104 | 1.4.1.4 | **Write Portion of RMP Chapter on Affected Environment** |  | 25d | 2010-04-09 | 2010-05-13 |  | 95d |  |
| 105 | 1.4.1.4.1 | Develop Narrative, Tables, Maps, etc. |  | 10d | 2010-04-09 | 2010-04-22 | 103 | 95d | 0d |
| 106 | 1.4.1.4.2 | Review Draft Chapter |  | 10d | 2010-04-23 | 2010-05-06 | 105 | 95d | 0d |
| 107 | 1.4.1.4.3 | Incorporate Comments |  | 5d | 2010-05-07 | 2010-05-13 | 106 | 95d | 0d |
| 108 | 1.4.1.4.4 | Chapter on Affected Environment Complete | milestone | 0d | 2010-05-13 | 2010-05-13 | 107 | 95d |  |
| 109 | 1.4.2 | **Formulate Alternatives (Contractor As Support Not Lead)** |  | 360d | 2010-02-26 | 2011-07-29 |  | 30d |  |
| 110 | 1.4.2.1 | **Continued Public/Interagency Involvement** |  | 360d | 2010-02-26 | 2011-07-29 |  | 133d |  |
| 111 | 1.4.2.1.1 | Field Trips |  | 360d | 2010-02-26 | 2011-07-29 | 98 | 133d |  |
| 112 | 1.4.2.1.2 | Meetings |  | 360d | 2010-02-26 | 2011-07-29 | 98 | 133d |  |
| 113 | 1.4.2.1.3 | Tribal Consultation |  | 360d | 2010-02-26 | 2011-07-29 | 98 | 133d |  |
| 114 | 1.4.2.2 | **Alternative Matrix & Text Descriptions** |  | 130d | 2010-04-09 | 2010-10-12 |  | 0d |  |
| 115 | 1.4.2.2.1 | Define Development Strategy for Alternatives |  | 5d | 2010-04-09 | 2010-04-15 | 103, 100 | 0d |  |
| 116 | 1.4.2.2.2 | Develop Preliminary Alternative Matrix |  | 5d | 2010-04-16 | 2010-04-22 | 115 | 0d |  |
| 117 | 1.4.2.2.3 | Subteam Review Iteration #1 |  | 20d | 2010-04-23 | 2010-05-20 | 116 | 0d |  |
| 118 | 1.4.2.2.4 | Subteam Review Iteration #2 |  | 20d | 2010-05-21 | 2010-06-18 | 117 | 0d |  |
| 119 | 1.4.2.2.5 | Subteam Review Iteration #3 |  | 20d | 2010-06-21 | 2010-07-19 | 118 | 0d |  |
| 120 | 1.4.2.2.6 | Identify Actions Common to All Alternatives |  | 10d | 2010-07-20 | 2010-08-02 | 119 | 0d |  |
| 121 | 1.4.2.2.7 | Sort Into Alternatives to Analyze & Not Analyzed |  | 5d | 2010-08-03 | 2010-08-09 | 120 | 0d |  |
| 122 | 1.4.2.2.8 | Finalize Alternative Matrix |  | 10d | 2010-08-10 | 2010-08-23 | 121 | 0d |  |
| 123 | 1.4.2.2.9 | Alternative Matrix Finalized | milestone | 0d | 2010-08-23 | 2010-08-23 | 122 | 0d |  |
| 124 | 1.4.2.2.10 | GIS |  | 80d | 2010-04-16 | 2010-08-09 | 115 | 10d |  |
| 125 | 1.4.2.2.11 | FO Review of Alternative Matrix |  | 20d | 2010-08-24 | 2010-09-21 | 124, 123 | 0d |  |
| 126 | 1.4.2.2.12 | Incorporate FO Comments |  | 5d | 2010-09-22 | 2010-09-28 | 125 | 0d |  |
| 127 | 1.4.2.2.13 | Expand Matrix into text descriptions |  | 10d | 2010-09-29 | 2010-10-12 | 126, 108 | 0d |  |

Notes:
- 112: Continuation of public involvement is required through the alternative development stage. Continue collaborative involvement strategies including field trips, meetings, and tribal consultation. Determine and accomplish logistics for all field trips, meetings, and tribal consultations. Facilitate field trips, meetings, and tribal consultations.
- 116: Formulate a minimum of three reasonable RMP alternatives, which focus on issue resolution and opportunities to institutionalize new planning concepts. The RMP alternatives will be consistent with the requirements of the new BLM Planning Handbook Appendix C. The land use planning alternatives are drafted and cooperating agencies are provided an opportunity to comment on them before incorporation into the RMP and EIS process.

| ID | WBS | Task | Type | Duration | Start | Finish | Predecessors | Total slack | Free slack |
| --- | --- | --- | --- | --- | --- | --- | --- | --- | --- |
| 128 | 1.4.2.3 | **SO Review of Alternatives** |  | 15d | 2010-10-13 | 2010-11-02 | 127 | 0d |  |
| 129 | 1.4.2.3.1 | SO Review Draft Chapter |  | 10d | 2010-10-13 | 2010-10-26 | 124 | 0d |  |
| 130 | 1.4.2.3.2 | Incorporate SO Comments |  | 5d | 2010-10-27 | 2010-11-02 | 129 | 0d |  |
| 131 | 1.4.2.3.3 | Alternatives Formulated | milestone | 0d | 2010-11-02 | 2010-11-02 | 130 | 0d |  |
| 132 | 1.4.3 | **Estimate Environmental Impacts (Impact Analysis)** |  | 50d | 2010-11-03 | 2011-01-18 |  | 0d |  |
| 133 | 1.4.3.1 | Prepare reasonably foreseeable future action (RFFA) scenarios |  | 10d | 2010-11-03 | 2010-11-16 | 131 | 0d |  |
| 134 | 1.4.3.2 | Prepare reasonably foreseeable development (RFD) scenarios |  | 10d | 2010-11-17 | 2010-12-02 | 131, 133 | 0d |  |
| 135 | 1.4.3.3 | Estimate Environmental Impacts of Alternatives |  | 10d | 2010-12-03 | 2010-12-16 | 131, 134 | 0d |  |
| 136 | 1.4.3.4 | Write RMP Chapter on Impact Analysis |  | 5d | 2010-12-17 | 2010-12-23 | 135 | 0d |  |
| 137 | 1.4.3.5 | Review Draft Chapter |  | 10d | 2010-12-28 | 2011-01-11 | 136 | 0d |  |
| 138 | 1.4.3.6 | Incorporate Comments |  | 5d | 2011-01-12 | 2011-01-18 | 137 | 0d |  |
| 139 | 1.4.4 | **Initiate Draft Biological Assessment (BA)** |  | 35d | 2010-12-28 | 2011-02-16 |  | 339d |  |
| 140 | 1.4.4.1 | Develop Draft of BA |  | 20d | 2010-12-28 | 2011-01-26 | 136 | 339d | 0d |
| 141 | 1.4.4.2 | Review Draft BA |  | 10d | 2011-01-27 | 2011-02-09 | 140 | 339d | 0d |
| 142 | 1.4.4.3 | Incorporate Comments to Draft BA |  | 5d | 2011-02-10 | 2011-02-16 | 141 | 339d | 248d |
| 143 | 1.4.5 | **Select Preferred Alternative** |  | 5d | 2011-01-19 | 2011-01-26 |  | 0d |  |
| 144 | 1.4.5.1 | Revise & Complete RMP Chapter on Alternatives |  | 5d | 2011-01-19 | 2011-01-26 | 138 | 0d |  |
| 145 | 1.4.5.2 | Preferred Alternative Selected | milestone | 0d | 2011-01-26 | 2011-01-26 | 144 | 0d |  |
| 146 | 1.4.6 | **RMP Chapter on Purpose & Need** |  | 20d | 2011-01-27 | 2011-02-23 |  | 0d |  |
| 147 | 1.4.6.1 | Compile Figures, Tables, Maps for RMP Chapter on Purpose & Need |  | 3d | 2011-01-27 | 2011-01-31 | 145 | 0d |  |
| 148 | 1.4.6.2 | Write RMP Chapter on Purpose & Need |  | 2d | 2011-02-01 | 2011-02-02 | 147 | 0d |  |
| 149 | 1.4.6.3 | Review Draft Chapter |  | 10d | 2011-02-03 | 2011-02-16 | 148 | 0d |  |
| 150 | 1.4.6.4 | Incorporate Comments |  | 5d | 2011-02-17 | 2011-02-23 | 149 | 0d |  |
| 151 | 1.4.7 | **RMP Chapter on Consultation & Coordination** |  | 32d | 2011-02-24 | 2011-04-08 |  | 0d |  |
| 152 | 1.4.7.1 | **Document formal consultations** |  | 12d | 2011-02-24 | 2011-03-11 |  | 0d |  |
| 153 | 1.4.7.1.1 | Native American |  | 3d | 2011-02-24 | 2011-02-28 | 150 | 0d |  |
| 154 | 1.4.7.1.2 | USFWS (Section 7) |  | 3d | 2011-03-01 | 2011-03-03 | 153 | 0d |  |
| 155 | 1.4.7.1.3 | Cultural (Section 106) |  | 3d | 2011-03-04 | 2011-03-08 | 154 | 0d |  |
| 156 | 1.4.7.1.4 | Others |  | 3d | 2011-03-09 | 2011-03-11 | 155 | 0d |  |
| 157 | 1.4.7.2 | Compile & Write RMP Chapter on Consultation & Coordination |  | 5d | 2011-03-14 | 2011-03-18 | 156 | 0d |  |
| 158 | 1.4.7.3 | Review Draft Chapter |  | 10d | 2011-03-21 | 2011-04-01 | 157 | 0d |  |
| 159 | 1.4.7.4 | Incorporate Comments |  | 5d | 2011-04-04 | 2011-04-08 | 158 | 0d |  |

Notes:
- 135: Prepare analysis assumptions. Prepare reasonably foreseeable future action (RFFA) and/or reasonably foreseeable development (RFD) scenarios over the life of the plan for those resource uses that have projected activity levels or anticipate large scale developments. RFFAs will also be developed where a resource use proposes restrictive measures upon other resource uses. Examples of RFFA/RFD needs include, but are not limited to: mineral development activities (RFD development standard for fluid minerals is found in BLM Handbook H-1624-1, Planning for Fluid Mineral Resources, Section III.4.), fire (i.e., prescribed burns), recreation (i.e. visitor use levels), timber sales, large scale water development projects (i.e. dams, reservoirs), wildlife re-introductions, large scale realty actions, etc.
- 140: Write the Biological Assessment (BA) for Section 7 Consultation with the U.S. Fish and Wildlife Service. The BA shall be guided by the Regulations on Interagency Cooperation (Section 7 of the Endangered Species Act) in 50 CFR section 402 and BLM Manual 6840.
- 147: Compile draft of Figures, Tables, and Maps. Write draft of Chapter 1: Introduction. Topics included are; Historical Background, Purpose and Need, Public Scoping/Issue Identification, Issues and Alternatives Considered for Detailed Analysis, Issues and Alternatives Rejected for Detailed Analysis, Planning Criteria, Conformance with Land Use Plans, and Relationship to Ongoing Programs, Plans, and Policies.

| ID | WBS | Task | Type | Duration | Start | Finish | Predecessors | Total slack | Free slack |
| --- | --- | --- | --- | --- | --- | --- | --- | --- | --- |
| 160 | 1.4.8 | **RMP Appendicies, Glossary, References** |  | 17d | 2011-04-11 | 2011-05-03 |  | 0d |  |
| 161 | 1.4.8.1 | Compile & Write Appendicies, Glossary, References |  | 10d | 2011-04-11 | 2011-04-22 | 159 | 0d |  |
| 162 | 1.4.8.2 | Review Draft Chapter |  | 5d | 2011-04-25 | 2011-04-29 | 161 | 0d |  |
| 163 | 1.4.8.3 | Incorporate Comments |  | 2d | 2011-05-02 | 2011-05-03 | 162 | 0d |  |
| 164 | 1.4.9 | **Complete Internal Draft of RMP/EIS** |  | 5d | 2011-05-04 | 2011-05-10 |  | 0d |  |
| 165 | 1.4.9.1 | Consolidatation of Internal Draft RMP/EIS |  | 5d | 2011-05-04 | 2011-05-10 | 163 | 0d |  |
| 166 | 1.4.9.2 | Consolidatation of Internal Draft RMP/EIS Complete | milestone | 0d | 2011-05-10 | 2011-05-10 | 165 | 0d |  |
| 167 | 1.4.10 | **Internal Reviews of Draft RMP/EIS** |  | 40d | 2011-05-11 | 2011-07-07 |  | 0d |  |
| 168 | 1.4.10.1 | IDT/FO Review |  | 20d | 2011-05-11 | 2011-06-08 | 166 | 0d |  |
| 169 | 1.4.10.2 | Incorporate Comments from IDT/FO Review |  | 5d | 2011-06-09 | 2011-06-15 | 168 | 0d |  |
| 170 | 1.4.10.3 | State Office Review and Approval (Internal Draft RMP) |  | 10d | 2011-06-16 | 2011-06-29 | 169 | 0d |  |
| 171 | 1.4.10.4 | Incorporate Comments of SO Review |  | 5d | 2011-06-30 | 2011-07-07 | 170 | 0d |  |
| 172 | 1.4.10.5 | Cooperating Agency Review |  | 20d | 2011-05-11 | 2011-06-08 | 166 | 15d | 0d |
| 173 | 1.4.10.6 | Incorporate Comments from Cooperative Agency Reviews |  | 5d | 2011-06-09 | 2011-06-15 | 172 | 15d |  |
| 174 | 1.4.11 | **Issue Draft RMP/EIS, Notice of Availability** |  | 85d | 2011-05-11 | 2011-09-09 |  | 0d |  |
| 175 | 1.4.11.1 | WO Review and Approval (Draft RMP) |  | 40d | 2011-07-08 | 2011-09-01 | 173, 171 | 0d |  |
| 176 | 1.4.11.2 | Incorporate WO Comments to Preliminary Draft RMP |  | 5d | 2011-09-02 | 2011-09-09 | 175 | 0d |  |
| 177 | 1.4.11.3 | Write NOA (Draft RMP) |  | 1d | 2011-05-11 | 2011-05-11 | 168SS | 62d | 0d |
| 178 | 1.4.11.4 | WO Approve NOA (Draft RMP) |  | 20d | 2011-05-12 | 2011-06-09 | 177 | 62d | 0d |
| 179 | 1.4.11.5 | Incorporate WO Comments to Draft NOA |  | 2d | 2011-06-10 | 2011-06-13 | 178 | 62d |  |
| 180 | 1.4.12 | **Print & Distribute Draft RMP** |  | 45d | 2011-09-12 | 2011-11-11 |  | 0d |  |
| 181 | 1.4.12.1 | Print Draft RMP |  | 30d | 2011-09-12 | 2011-10-21 | 179, 176 | 0d |  |
| 182 | 1.4.12.2 | Distribute Draft RMP | milestone | 5d | 2011-10-24 | 2011-10-28 | 181 | 0d |  |
| 183 | 1.4.12.3 | Distribute Draft RMP to EPA |  | 5d | 2011-10-24 | 2011-10-28 | 181 | 0d |  |
| 184 | 1.4.12.4 | Issue NOA (Draft RMP) in Federal Register |  | 10d | 2011-10-31 | 2011-11-11 | 182, 179 | 0d |  |
| 185 | 1.4.12.5 | Issue NOA (Draft RMP) to EPA |  | 10d | 2011-10-31 | 2011-11-11 | 183 | 0d |  |
| 186 | 1.4.12.6 | NOA for Draft RMP/EIS Published | milestone | 0d | 2011-11-11 | 2011-11-11 | 184 | 0d |  |

Notes:
- 170: The Field Manager and District Manager recommend to the State Director a preferred alternative that best resolves planning issues and promotes balanced multiple use objectives. The State Director approves the selection of the preferred alternative along with the other alternatives under consideration.
- 175: State Office review of Preliminary Draft RMP/EIS. Washington Office review of Preliminary Draft RMP/EIS. Respond to SO & WO comments to Preliminary Draft RMP/EIS. Finalize Draft RMP/EIS.

| ID | WBS | Task | Type | Duration | Start | Finish | Predecessors | Total slack | Free slack | Resources | Work |
| --- | --- | --- | --- | --- | --- | --- | --- | --- | --- | --- | --- |
| 187 | 1.5 | **Proposed RMP/Final EIS, NOA for Proposed RMP/Final EIS, Governor's Consistency Review** |  | 328d | 2011-11-11 | 2013-03-05 |  | 0d |  |  | 2400h |
| 188 | 1.5.1 | **Public Review and Comment** |  | 59d | 2011-11-11 | 2012-02-09 |  | 0d |  |  | 720h |
| 189 | 1.5.1.1 | Start Proposed RMP/Final EIS | milestone | 0d | 2011-11-11 | 2011-11-11 | 186 | 0d |  |  |  |
| 190 | 1.5.1.2 | Public Review & Comment Period (Calendar Days) |  | 90d | 2011-11-12 | 2012-02-09 | 182, 184, 183, 185, 189 | 0d |  | Calendar Days | 720h |
| 191 | 1.5.1.3 | Conduct Public Outreach |  | 40d | 2011-11-14 | 2012-01-12 | 190SS | 19d |  |  |  |
| 192 | 1.5.1.4 | Public Comment Period Ends | milestone | 0d | 2012-02-09 | 2012-02-09 | 190, 191, 111, 112, 113 | 0d |  |  |  |
| 193 | 1.5.2 | **Comment Analysis & Resolution** |  | 60d | 2012-02-10 | 2012-05-03 |  | 0d |  |  |  |
| 194 | 1.5.2.1 | Review, Analyze, Summarize comments |  | 15d | 2012-02-10 | 2012-03-01 | 190, 192, 189 | 0d |  |  |  |
| 195 | 1.5.2.2 | Evaluate Comments |  | 20d | 2012-03-02 | 2012-03-29 | 194 | 0d |  |  |  |
| 196 | 1.5.2.3 | Formulate Comment Response & Plan Changes |  | 15d | 2012-03-30 | 2012-04-19 | 195 | 0d |  |  |  |
| 197 | 1.5.2.4 | Incorporate Plan Changes Based on Comments |  | 10d | 2012-04-20 | 2012-05-03 | 196 | 0d |  |  |  |
| 198 | 1.5.2.5 | Draft Plan Revised for Public Comments | milestone | 0d | 2012-05-03 | 2012-05-03 | 197 | 0d |  |  |  |
| 199 | 1.5.3 | **Finalize BA** |  | 94d | 2012-02-10 | 2012-06-21 |  | 89d |  |  | 960h |
| 200 | 1.5.3.1 | Finalize BA |  | 5d | 2012-02-10 | 2012-02-16 | 142, 190 | 91d | 0d |  |  |
| 201 | 1.5.3.2 | BLM Review of BA |  | 2d | 2012-02-17 | 2012-02-20 | 200 | 91d | 0d |  |  |
| 202 | 1.5.3.3 | Incorporate BLM Comments |  | 1d | 2012-02-21 | 2012-02-21 | 201 | 91d | 0d |  |  |
| 203 | 1.5.3.4 | Distribute to FWS |  | 1d | 2012-02-22 | 2012-02-22 | 202 | 91d | 0d |  |  |
| 204 | 1.5.3.5 | FWS Biological Opinion (120 Calendar Days) |  | 120d | 2012-02-23 | 2012-06-21 | 203 | 89d |  | Calendar Days | 960h |
| 205 | 1.5.4 | **Internal Reviews of Proposed RMP/Final EIS** |  | 55d | 2012-05-04 | 2012-07-23 |  | 0d |  |  |  |
| 206 | 1.5.4.1 | IDT Review |  | 10d | 2012-05-04 | 2012-05-17 | 198 | 0d |  |  |  |
| 207 | 1.5.4.2 | Incorporate Comments from IDT Review |  | 5d | 2012-05-18 | 2012-05-24 | 206 | 0d |  |  |  |
| 208 | 1.5.4.3 | State Office Review and Approval (Internal Proposed RMP) |  | 10d | 2012-05-25 | 2012-06-08 | 207 | 0d |  |  |  |
| 209 | 1.5.4.4 | Incorporate Comments of SO Review |  | 5d | 2012-06-11 | 2012-06-15 | 208 | 0d |  |  |  |
| 210 | 1.5.4.5 | Cooperating Agency Review |  | 20d | 2012-06-18 | 2012-07-16 | 209 | 0d |  |  |  |
| 211 | 1.5.4.6 | Incorporate Comments from Cooperative Agency Reviews |  | 5d | 2012-07-17 | 2012-07-23 | 210 | 0d |  |  |  |
| 212 | 1.5.4.7 | Internal Reviews of Proposed RMP/Final EIS Complete | milestone | 0d | 2012-07-23 | 2012-07-23 | 211, 209 | 0d |  |  |  |

Notes:
- 190: Public input via written responses within the 90-day review and comment period.
- 194: All documentation will be BLM website compatible. Prepare a system to document and track all public comments. Gather, screen, and evaluate comments from public, private, and tribal, sources. Categorize comments as Included or Not Included.
- 197: Prepare for review by the BLM interdisciplinary team (ID) proposed changes to the PRMP/FEIS based on public comment. Incorporate the comments of the ID team and prepare the preliminary PRMP/FEIS for review by the BLM Management Team. Based on BLM Management Team comments, prepare a draft of the PRMP/FEIS.
- 208: State Office review of PRMP/FEIS. Washington Office review of PRMP/FEIS. Respond to SO & WO comments to PRMP/FEIS. Finalize PRMP/FEIS.

| ID | WBS | Task | Type | Duration | Start | Finish | Predecessors | Total slack | Free slack | Resources | Work |
| --- | --- | --- | --- | --- | --- | --- | --- | --- | --- | --- | --- |
| 213 | 1.5.5 | **Issue Proposed RMP/Final EIS, Notice of Availability** |  | 68d | 2012-07-24 | 2012-10-26 |  | 0d |  |  |  |
| 214 | 1.5.5.1 | WO Review and Approval (Proposed RMP) |  | 40d | 2012-07-24 | 2012-09-18 | 212 | 0d |  |  |  |
| 215 | 1.5.5.2 | Incorporate WO Comments to Proposed RMP |  | 5d | 2012-09-19 | 2012-09-25 | 214 | 0d |  |  |  |
| 216 | 1.5.5.3 | Write NOA (Proposed RMP) |  | 1d | 2012-09-26 | 2012-09-26 | 214, 215 | 0d |  |  |  |
| 217 | 1.5.5.4 | WO Approve NOA (Proposed RMP) |  | 20d | 2012-09-27 | 2012-10-24 | 216 | 0d |  |  |  |
| 218 | 1.5.5.5 | Incorporate WO Comments to Draft NOA (Proposed RMP) |  | 2d | 2012-10-25 | 2012-10-26 | 217 | 0d |  |  |  |
| 219 | 1.5.6 | **Print & Distribute Proposed RMP/ Final EIS** |  | 45d | 2012-10-29 | 2013-01-04 |  | 0d |  |  |  |
| 220 | 1.5.6.1 | Print Proposed RMP/FEIS |  | 30d | 2012-10-29 | 2012-12-11 | 218, 204 | 0d |  |  |  |
| 221 | 1.5.6.2 | Distribute Proposed RMP/FEIS | milestone | 5d | 2012-12-12 | 2012-12-18 | 220 | 0d |  |  |  |
| 222 | 1.5.6.3 | Distribute Proposed RMP/FEIS to EPA |  | 1d | 2012-12-12 | 2012-12-12 | 220 | 9d | 0d |  |  |
| 223 | 1.5.6.4 | Issue NOA (Proposed RMP/FEIS) in Federal Register |  | 10d | 2012-12-19 | 2013-01-04 | 221 | 0d |  |  |  |
| 224 | 1.5.6.5 | Issue NOA (Proposed RMP/FEIS) to EPA |  | 5d | 2012-12-13 | 2012-12-19 | 222 | 9d |  |  |  |
| 225 | 1.5.6.6 | NOA for Proposed RMP/FEIS Published | milestone | 0d | 2013-01-04 | 2013-01-04 | 223, 224 | 0d |  |  |  |
| 226 | 1.5.7 | **Governor's Consistency Review** |  | 41d | 2013-01-05 | 2013-03-05 |  | 0d |  |  | 480h |
| 227 | 1.5.7.1 | Governor's Consistency Review (Calendar Days) |  | 60d | 2013-01-05 | 2013-03-05 | 225 | 0d |  | Calendar Days | 480h |
| 228 | 1.5.7.2 | Governor's Consistency Review Complete | milestone | 0d | 2013-03-05 | 2013-03-05 | 227 | 0d |  |  |  |
| 229 | 1.5.8 | **Protest Period** |  | 19d | 2013-01-05 | 2013-02-03 |  | 14d |  |  | 240h |
| 230 | 1.5.8.1 | Protest Period (Calendar Days) |  | 30d | 2013-01-05 | 2013-02-03 | 225 | 14d | 0d | Calendar Days | 240h |
| 231 | 1.6 | **Resolve Protests, Sign Record of Decision** |  | 93d | 2013-02-04 | 2013-06-13 |  | 0d |  |  |  |
| 232 | 1.6.1 | **Resolve Governor's Consistency Review Comments** |  | 10d | 2013-03-06 | 2013-03-19 |  | 0d |  |  |  |
| 233 | 1.6.1.1 | Respond to Governor's Comments |  | 10d | 2013-03-06 | 2013-03-19 | 228 | 0d |  |  |  |
| 234 | 1.6.2 | **Resolve Protests** |  | 72d | 2013-02-04 | 2013-05-14 |  | 0d |  |  |  |
| 235 | 1.6.2.1 | Review Protests |  | 10d | 2013-02-04 | 2013-02-15 | 230 | 17d | 0d |  |  |
| 236 | 1.6.2.2 | Analyze Protests |  | 5d | 2013-02-18 | 2013-02-22 | 235 | 17d |  |  |  |
| 237 | 1.6.2.3 | Develop Draft & Finalize Response for BLM Director |  | 30d | 2013-03-20 | 2013-04-30 | 236, 233 | 0d |  |  |  |
| 238 | 1.6.2.4 | Decision On Protests |  | 10d | 2013-05-01 | 2013-05-14 | 237 | 0d |  |  |  |
| 239 | 1.6.2.5 | Protests Resolved | milestone | 0d | 2013-05-14 | 2013-05-14 | 238 | 0d |  |  |  |

Notes:
- 235: Respond to and resolve protest(s) received on the plan: 1) analyze the protestants letter and develop a statement defining each issue raised, 2) determine if issue raised is germaine or valid, 3) prepare draft letter stating rationale for determining whether or not the issue is germane or valid, 4) prepare draft response to valid protest issues.

| ID | WBS | Task | Type | Duration | Start | Finish | Predecessors | Total slack |
| --- | --- | --- | --- | --- | --- | --- | --- | --- |
| 240 | 1.6.3 | **Notice of Significant Change (NOT Required)** |  | 1d | 2013-05-15 | 2013-05-15 |  | 0d |
| 241 | 1.6.3.1 | No Significant Changes |  | 1d | 2013-05-15 | 2013-05-15 | 239 | 0d |
| 242 | 1.6.4 | **Sign Record of Decision (ROD) Approving RMP** |  | 20d | 2013-05-16 | 2013-06-13 |  | 0d |
| 243 | 1.6.4.1 | Prepare ROD |  | 10d | 2013-05-16 | 2013-05-30 | 241 | 0d |
| 244 | 1.6.4.2 | Approve ROD |  | 5d | 2013-05-31 | 2013-06-06 | 243 | 0d |
| 245 | 1.6.4.3 | Record of Decision | milestone | 0d | 2013-06-06 | 2013-06-06 | 244, 6, 8, 10 | 0d |
| 246 | 1.6.4.4 | Print & Distribute ROD |  | 5d | 2013-06-07 | 2013-06-13 | 245 | 0d |
| 247 | 1.7 | **Project Closeout** |  | 10d | 2013-06-14 | 2013-06-27 |  | 0d |
| 248 | 1.7.1 | Project Lessons Learned |  | 10d | 2013-06-14 | 2013-06-27 | 246 | 0d |
| 249 | 1.8 | **Implementation Plan** |  | 0d | 2013-06-06 | 2013-06-06 |  | 15d |
| 250 | 1.8.1 | Develop implementation and tracking system | milestone | 0d | 2013-06-06 | 2013-06-06 | 244 | 15d |

Notes:
- 243: Prepare Record of Decision (ROD) and the Resource Management Plan (RMP). May include but is not limited to the following: 1) meet with BLM management concerning the ROD and RMP contents, 2) draft the ROD and RMP for BLM review, 3) finalize the ROD and RMP, 4) print and distribute the ROD and RMP.
- 250: Prepare an implementation and tracking system of decisions within the plan.
